# MAPS Inner Barrel

Schedule from MS Project, 2016-10-03 to 2019-09-30, costs in $, A marks actual dates.
Guest Scientist, LANL

## Calendars

- Standard: Mon-Fri 08:00-12:00, 13:00-17:00; Sat-Sun off.

## Resources

| Resource | Rate | Cost per use |
| --- | --- | --- |
| Mech Liason Eng | 130 |  |
| Elec Liason Eng | 130 |  |
| Project Manager | 130 |  |
| Physicist |  |  |
| Elec tech | 97 |  |
| Mech Tech | 97 |  |
| Electronics Engineer | 130 |  |
| Mechanical Engineer | 130 |  |
| M&S |  | 1 |
| Electrical Engineer | 130 |  |
| LDRD Physicist | 230 |  |
| LDRD PostDoc | 90 |  |
| LDRD Electronics Engineer | 230 |  |
| LDRD Mechnical Engineer | 230 |  |
| LDRD Mechnical Tech | 150 |  |
| LDRD Electronics Tech | 150 |  |

## Schedule

| ID | WBS | Task | Type | Duration | Start | Finish | Predecessors | Complete | Remaining | Total slack | Free slack | Constraint | Resources | Work | Actual work | Cost | Actual cost | Activity | Cost Center |
| --- | --- | --- | --- | --- | --- | --- | --- | --- | --- | --- | --- | --- | --- | --- | --- | --- | --- | --- | --- |
| 1 | 1 | **ALICE ITS Key Tasks** |  | 0d | 2017-01-02 | 2017-01-02 |  |  |  |  |  |  |  |  |  |  |  |  |  |
| 2 | 1.1 | ALICE MAPS Production (7/17) |  | 240d? | 2016-11-28 | 2017-10-27 |  |  |  | 501d |  | start no earlier than 2016-11-28 |  |  |  |  |  |  |  |
| 3 | 1.2 | ALICE ITS IB FPC Production (9/17) |  | 90d | 2017-05-01 | 2017-09-01 |  |  |  | 541d |  | finish no earlier than 2017-09-01 |  |  |  |  |  |  |  |
| 4 | 1.3 | ALICE ITS IB Stave Frame Production Ends (1/18) |  | 240d? | 2017-02-01 | 2018-01-02 |  |  |  | 454d |  | start no earlier than 2017-02-01 |  |  |  |  |  |  |  |
| 5 | 1.4 | ALICE ITS IB Stave Assembly (3/18) |  | 266d | 2017-02-27 | 2018-03-05 |  |  |  | 410d | 0d | finish no earlier than 2018-03-05 |  |  |  |  |  | ITS construction |  |
| 6 | 1.5 | ALICE ITS Electronics Pre-Production (7/17) |  | 100d | 2017-03-13 | 2017-07-28 |  |  |  | 139d | 0d | start no earlier than 2017-03-13 |  |  |  |  |  | ITS Electronics Pre-Production |  |
| 7 | 1.6 | ALICE ITS Electronics Production (6/18) |  | 240d | 2017-07-31 | 2018-06-29 | 6 |  |  | 326d |  | start no earlier than 2017-07-13 |  |  |  |  |  | ITS Electronics Production |  |
| 8 | 2 | **LDRD Milestones & Critical Tasks** |  | 781d | 2016-10-03 | 2019-09-30 |  |  |  | 0d |  |  |  |  |  |  |  |  |  |
| 9 | 2.1 | LDRD Start and End |  | 781d | 2016-10-03 | 2019-09-30 |  |  |  | 0d |  | start no earlier than 2016-10-03 |  |  |  |  |  |  |  |
| 10 | 2.2 | Complete MoU LANL-ALICE | milestone | 0d | 2016-12-09 | 2016-12-09 | 17 |  |  | 254d | 0d |  |  |  |  |  |  |  |  |
| 11 | 2.3 | Setup ALICE Readout Test Stands | milestone | 0d | 2017-06-09 | 2017-06-09 | 24 |  |  | 601d |  |  |  |  |  |  |  |  |  |
| 12 | 2.4 | Preliminary sPHENIX readout design (CD-1) | milestone | 0d | 2017-11-01 | 2017-11-01 | 50 |  |  | 499d |  | start no earlier than 2017-11-01 |  |  |  |  |  |  |  |
| 13 | 2.5 | Complete Final MAPS Detector Design (CD-2) | milestone | 0d | 2018-08-02 | 2018-08-02 | 81 |  |  | 302d |  |  |  |  |  |  |  |  |  |
| 14 | 2.6 | MAPS Final Design (CD-2/CD-3) | milestone | 0d | 2018-08-31 | 2018-08-31 | 81 |  |  | 282d |  | start no earlier than 2018-08-31 |  |  |  |  |  |  |  |
| 15 | 2.7 | Prototype Test with sPHENIX Test Beam |  | 21d | 2019-02-01 | 2019-03-01 |  |  |  | 151d |  | start no earlier than 2019-02-01 |  |  |  |  |  |  | LDRD |
| 16 | 3 | **LANL LDRD** |  | 781d | 2016-10-03 A | 2019-09-30 |  | 1% | 773.65d | 0d |  |  |  | 16842h | 40h | 2,138,400 | 9,828 | LANL R&D | LDRD |
| 17 | 3.1 | MOU btw LANL and ALICE for R&D |  | 50d | 2016-10-03 | 2016-12-09 |  |  |  | 0d |  | start no earlier than 2016-10-03 | LDRD Physicist [20%] | 80h |  | 18,400 |  |  | LDRD |
| 18 | 3.2 | **Obtain Designs from ALICE** |  | 30d | 2016-12-12 | 2017-01-20 |  |  |  | 0d |  |  |  | 720h |  | 82,800 |  |  |  |
| 19 | 3.2.1 | Obtain Test Stand Design from CERN | milestone | 30d | 2016-12-12 | 2017-01-20 | 17 |  |  | 0d |  | start no earlier than 2016-10-03 | LDRD Electronics Engineer [50%]; Physicist [50%] | 240h |  | 27,600 |  |  | LDRD |
| 20 | 3.2.2 | Obtain ALICE Readout Unit Design | milestone | 30d | 2016-12-12 | 2017-01-20 | 17 |  |  | 174d | 0d |  | Physicist [50%]; LDRD Electronics Engineer [50%] | 240h |  | 27,600 |  |  | LDRD |
| 21 | 3.2.3 | obtain ALICE CAD model | milestone | 30d | 2016-12-12 | 2017-01-20 | 17 |  |  | 344d | 0d | start no earlier than 2016-06-01 | Physicist [50%]; LDRD Mechnical Engineer [50%] | 240h |  | 27,600 |  | ALICE CAD model | LDRD |
| 22 | 3.3 | **Setup Alice Readout Test Stand** |  | 130d | 2016-12-12 A | 2017-06-09 |  | 23% | 100d | 601d | 0d |  |  | 192h | 40h | 52,080 | 9,828 |  | LDRD |
| 23 | 3.3.1 | Procure 2 Test Stands |  | 120d | 2016-12-12 A | 2017-05-26 | 19 | 25% | 90d | 587d | 0d |  | Elec tech [5%]; Physicist [5%] | 56h | 40h | 33,880 | 9,828 |  | LDRD |
| 24 | 3.3.2 | Setup Test Stands |  | 10d | 2017-05-29 | 2017-06-09 | 23 |  |  | 601d | 0d |  | Physicist [20%]; LDRD PostDoc; LDRD Electronics Tech [50%] | 136h |  | 18,200 |  |  | LDRD |

Notes:
- 12: LDRD complete full readout electronics final design
- 16: LANL LDRD activities
- 17: Use ITS production line to train local people and produce staves for sPHENIX; / provide 1 FTE from 1/2017 - 6/2018+ for LDRD and later for sPHENIX
- 19: The readout test stand design has already been completed by ALICE.
- 21: Walt already obtained CAD model
- 23: Cost from Leo. Only a few custom boards, standard items standard: power supplies, etc. One stand would be procured early, one late, both under LDRD. / CERN-LANL MOU comes later in 2016, ~Dec. 2016? / Time needed to setup an CERN accout etc. may delay the actual procument date. MXL
- 24: LDRD PD + Tech, working with external collaorators/physicists

| ID | WBS | Task | Duration | Start | Finish | Predecessors | Total slack | Free slack | Constraint | Resources | Work | Cost | Cost Center |
| --- | --- | --- | --- | --- | --- | --- | --- | --- | --- | --- | --- | --- | --- |
| 25 | 3.4 | **Procure R&D ALICE Staves** | 185d | 2017-02-27 | 2017-11-10 |  | 214d |  |  |  | 3680h | 438,480 | LDRD |
| 26 | 3.4.1 | Procure and Produce 4 Staves | 180d | 2017-02-27 | 2017-11-03 | 17, 5SS | 214d | 0d |  | Physicist [50%]; LDRD Electronics Tech; LDRD PostDoc | 3600h | 400,600 | LDRD |
| 27 | 3.4.2 | Test Staves at LANL | 10d | 2017-10-30 | 2017-11-10 | 26FS-5d | 214d | 75d |  | LDRD Physicist [20%]; LDRD PostDoc [50%]; LDRD Electronics Tech [30%] | 80h | 10,880 | LDRD |
| 28 | 3.4.3 | Travel and Per Diem Support | 180d | 2017-02-27 | 2017-11-03 | 26SS | 496d |  |  |  |  | 27,000 | LDRD |
| 29 | 3.5 | **Procure ALICE Electronics & Cables** | 375d | 2016-12-12 | 2018-05-18 |  | 204d |  |  |  | 694.4h | 122,812 | LDRD |
| 30 | 3.5.1 | **ALICE Readout Electronics Boards** | 140d | 2017-03-13 | 2017-09-22 |  | 139d |  |  |  | 486.4h | 64,920 |  |
| 31 | 3.5.1.1 | **Readout Units (RDOs)** | 140d | 2017-03-13 | 2017-09-22 |  | 139d |  |  |  | 272h | 30,280 |  |
| 32 | 3.5.1.1.1 | Procure 4 RDOs | 120d | 2017-03-13 | 2017-08-25 | 6SS, 17FS+1d | 139d | 0d |  | Physicist [5%]; LDRD Electronics Tech [5%] | 96h | 12,200 | LDRD |
| 33 | 3.5.1.1.2 | Test RDOs | 20d | 2017-08-28 | 2017-09-22 | 32 | 139d | 0d |  | Physicist [20%]; LDRD Electronics Tech [30%]; LDRD PostDoc [50%]; LDRD Physicist [10%] | 176h | 18,080 | LDRD |
| 34 | 3.5.1.2 | **Common Readout Units (CRUs)** | 140d | 2017-03-13 | 2017-09-22 |  | 139d |  |  |  | 214.4h | 34,640 |  |
| 35 | 3.5.1.2.1 | Procure 2 CRUs | 120d | 2017-03-13 | 2017-08-25 | 17FS+1d, 6SS | 139d | 0d |  | Physicist [2%]; LDRD Electronics Tech [2%] | 38.4h | 12,880 | LDRD |
| 36 | 3.5.1.2.2 | Test CRUs at LANL | 20d | 2017-08-28 | 2017-09-22 | 35 | 139d | 0d |  | Physicist [10%]; LDRD Electronics Tech [30%]; LDRD PostDoc [50%]; LDRD Physicist [20%] | 176h | 21,760 | LDRD |
| 37 | 3.5.2 | **SamTec Cables** | 32d | 2016-12-12 | 2017-01-24 |  | 312d |  |  |  | 20h | 5,000 |  |
| 38 | 3.5.2.1 | Procure 7 SamTec Cables | 30d | 2016-12-12 | 2017-01-20 | 10 | 312d | 0d |  | LDRD Electronics Tech [5%] | 12h | 3,800 | LDRD |
| 39 | 3.5.2.2 | Test Cables | 2d | 2017-01-23 | 2017-01-24 | 38 | 312d | 173d |  | LDRD Electronics Tech [50%] | 8h | 1,200 | LDRD |
| 40 | 3.5.3 | **Optical Cables** | 22d | 2016-12-13 | 2017-01-11 |  | 321d |  |  |  | 8h | 1,600 |  |
| 41 | 3.5.3.1 | Procure 4 Optical Cables | 20d | 2016-12-13 | 2017-01-09 | 38SS+1d | 321d | 0d |  | LDRD Electronics Tech [2%] | 3.2h | 880 | LDRD |
| 42 | 3.5.3.2 | Test Optical Cables | 2d | 2017-01-10 | 2017-01-11 | 41 | 321d | 182d |  | LDRD Electronics Tech [30%] | 4.8h | 720 | LDRD |
| 43 | 3.5.4 | **Procure Ancillaries** | 94d | 2016-12-13 | 2017-04-21 |  | 251d |  |  |  | 180h | 51,292 | LDRD |
| 44 | 3.5.4.1 | Procure LV,HV,etc | 90d | 2016-12-13 | 2017-04-17 | 22SS+1d | 251d | 0d | start no earlier than 2016-10-03 | Physicist [5%]; LDRD Electronics Tech [5%] | 72h | 30,400 | LDRD |
| 45 | 3.5.4.2 | Procure Racks | 90d | 2016-12-15 | 2017-04-19 | 44SS+2d | 251d | 0d | start no earlier than 2016-10-03 | LDRD Electronics Tech [5%] | 36h | 10,400 | LDRD |
| 46 | 3.5.4.3 | Procure Chiller | 90d | 2016-12-19 | 2017-04-21 | 45SS+2d | 542d | 15d |  | Physicist [5%]; Elec tech [5%] | 72h | 10,492 | LDRD |
| 47 | 3.5.5 | **Readout R&D** | 345d | 2017-01-23 | 2018-05-18 |  | 174d |  |  |  |  |  |  |
| 48 | 3.5.5.1 | Preliminary readout design | 120d | 2017-01-23 | 2017-07-07 | 10, 19, 20 | 174d | 0d |  |  |  |  |  |
| 49 | 3.5.5.2 | Preliminary test of RDO with test bench | 20d | 2017-07-10 | 2017-08-04 | 48 | 174d | 35d |  |  |  |  |  |
| 50 | 3.5.5.3 | Test Preliminary Readout Design with RDO and CRU | 20d | 2017-09-25 | 2017-10-20 | 33, 36, 39, 42, 44, 45, 49 | 139d | 0d |  |  |  |  |  |
| 51 | 3.5.5.4 | Readout design and test II | 90d | 2017-10-23 | 2018-02-23 | 50 | 139d | 0d |  |  |  |  |  |
| 52 | 3.5.5.5 | Readout final design | 60d | 2018-02-26 | 2018-05-18 | 51 | 332d | 0d |  |  |  |  |  |

Notes:
- 26: work on MOU to get 4 staves as early as possible; within 60 from the production ; / train LANL staff for MAPS assembly and test. M&S $20K for 6 months
- 27: assume testing 1 stave every two days;
- 28: $4.5K/month including lodging(100) and per diem (50) 1 FTE (combination of PD and staff) / for 6 months;
- 30: critical tasks
- 38: from DigiKey?

| ID | WBS | Task | Type | Duration | Start | Finish | Predecessors | Total slack | Free slack | Constraint | Resources | Work | Cost | Cost Center |
| --- | --- | --- | --- | --- | --- | --- | --- | --- | --- | --- | --- | --- | --- | --- |
| 53 | 3.6 | **Electronics Final Design Review** |  | 12d | 2018-05-21 | 2018-06-05 |  | 332d |  |  |  | 65.6h | 15,088 |  |
| 54 | 3.6.1 | Electronics Design Review |  | 1d | 2018-05-21 | 2018-05-21 | 33, 36, 23, 52 | 332d | 0d |  | LDRD Electronics Engineer; LDRD Physicist | 16h | 3,680 | LDRD |
| 55 | 3.6.2 | Incorporate Review Comments |  | 10d | 2018-05-22 | 2018-06-04 | 54 | 332d | 0d |  | LDRD Physicist [20%]; LDRD Electronics Engineer [30%] | 40h | 9,200 | LDRD |
| 56 | 3.6.3 | Complete Final Electronics Design | milestone | 1d | 2018-06-05 | 2018-06-05 | 55 | 332d | 30d |  | LDRD Physicist [20%]; LDRD Electronics Engineer | 9.6h | 2,208 | LDRD |
| 57 | 3.7 | **Mechanical Support and Cooling** |  | 160d | 2017-01-23 | 2017-09-01 |  | 344d |  |  |  | 992h | 214,360 |  |
| 58 | 3.7.1 | **Specifications** |  | 60d | 2017-01-23 | 2017-04-14 |  | 344d |  |  |  | 336h | 65,120 |  |
| 59 | 3.7.1.1 | Review & Simulate Heat Load |  | 40d | 2017-01-23 | 2017-03-17 | 21 | 344d | 0d | start no earlier than 2016-10-03 | LDRD Mechnical Engineer [30%]; LDRD Physicist [20%]; LDRD PostDoc [20%] | 224h | 42,560 | LDRD |
| 60 | 3.7.1.2 | review mechanical tolerances/distortions |  | 10d | 2017-03-20 | 2017-03-31 | 59 | 344d | 0d | start no earlier than 2004-10-01 | LDRD Mechnical Engineer [30%]; LDRD Physicist [30%] | 48h | 11,040 | LDRD |
| 61 | 3.7.1.3 | review disassembly/repair options |  | 10d | 2017-04-03 | 2017-04-14 | 60 | 344d | 0d | start no earlier than 2004-10-01 | LDRD Mechnical Tech [50%]; LDRD Physicist [30%] | 64h | 11,520 | LDRD |
| 62 | 3.7.2 | Prototype Stave Space Frame Design |  | 20d | 2017-04-17 | 2017-05-12 | 61 | 344d | 0d |  | LDRD Mechnical Engineer [50%]; LDRD Physicist [20%]; LDRD Mechnical Tech [30%] | 160h | 32,960 | LDRD |
| 63 | 3.7.3 | **Safety Systems** |  | 60d | 2017-06-12 | 2017-09-01 |  | 541d |  |  |  | 144h | 35,440 |  |
| 64 | 3.7.3.1 | review sensors & interlocks |  | 20d | 2017-06-12 | 2017-07-07 | 69 | 541d | 0d |  | LDRD Electronics Tech [30%] | 48h | 7,200 | LDRD |
| 65 | 3.7.3.2 | electrical interlock design |  | 20d | 2017-07-10 | 2017-08-04 | 64 | 541d | 0d |  | LDRD Electronics Tech [30%] | 48h | 12,200 | LDRD |
| 66 | 3.7.3.3 | cooling interlocks design |  | 20d | 2017-08-07 | 2017-09-01 | 65 | 541d |  |  | LDRD Mechnical Engineer [30%] | 48h | 16,040 | LDRD |
| 67 | 3.7.4 | **Cooling System** |  | 20d | 2017-05-15 | 2017-06-09 | 46, 61 | 527d |  |  |  | 136h | 32,480 |  |
| 68 | 3.7.4.1 | Prototype Design (modify ALICE) |  | 10d | 2017-05-15 | 2017-05-26 | 59, 62 | 527d | 0d |  | LDRD Mechnical Engineer [30%]; LDRD Physicist [20%] | 40h | 9,200 | LDRD |
| 69 | 3.7.4.2 | Mock up Testing |  | 10d | 2017-05-29 | 2017-06-09 | 68 | 541d | 0d |  | LDRD Mechnical Tech [50%]; LDRD Physicist [20%]; LDRD PostDoc [50%] | 96h | 23,280 | LDRD |
| 70 | 3.7.5 | **Stave Assembly Tooling** |  | 60d | 2017-05-29 | 2017-08-18 |  | 527d |  |  |  | 216h | 48,360 |  |
| 71 | 3.7.5.1 | Jig Design (modify ALICE) |  | 10d | 2017-05-29 | 2017-06-09 | 62, 68 | 527d | 0d |  | LDRD Mechnical Engineer [30%]; LDRD Physicist [10%] | 32h | 7,360 | LDRD |
| 72 | 3.7.5.2 | Prototype Jigs |  | 30d | 2017-06-12 | 2017-07-21 | 71 | 527d | 0d |  | LDRD PostDoc [20%]; LDRD Mechnical Tech [30%] | 120h | 20,120 | LDRD |
| 73 | 3.7.5.3 | Final Jigs Design and Production |  | 20d | 2017-07-24 | 2017-08-18 | 72 | 527d | 225d |  | LDRD Mechnical Engineer [10%]; LDRD Mechnical Tech [30%] | 64h | 20,880 | LDRD |
| 74 | 3.8 | **Mechanical Coneptual Design Review** |  | 12d | 2018-07-02 | 2018-07-17 |  | 302d |  |  |  | 104h | 23,920 |  |
| 75 | 3.8.1 | Mechanics Design Review |  | 1d | 2018-07-02 | 2018-07-02 | 69, 73, 84 | 302d | 0d |  | LDRD Mechnical Engineer; LDRD Physicist | 16h | 3,680 | LDRD |
| 76 | 3.8.2 | Incorporate Review Comments |  | 10d | 2018-07-03 | 2018-07-16 | 75 | 302d | 0d |  | LDRD Mechnical Engineer [50%]; LDRD Physicist [50%] | 80h | 18,400 | LDRD |
| 77 | 3.8.3 | Complete Mechanical Conceptual Design (for CD-1) | milestone | 1d | 2018-07-17 | 2018-07-17 | 76 | 302d | 0d |  | LDRD Physicist [50%]; LDRD Mechnical Engineer [50%] | 8h | 1,840 | LDRD |

Notes:
- 54: for CD-2
- 63: monitoring temp, flow rates, I, V etc.
- 74: For CD-1 review, 11/2017, conceptuall design of mechanis system

| ID | WBS | Task | Type | Duration | Start | Finish | Predecessors | Total slack | Free slack | Constraint | Resources | Work | Cost | DOE Cost | Cost Center |
| --- | --- | --- | --- | --- | --- | --- | --- | --- | --- | --- | --- | --- | --- | --- | --- |
| 78 | 3.9 | **MAPS Inner Barrel Review (CD-2/3)** |  | 12d | 2018-07-18 | 2018-08-02 |  | 302d |  |  |  | 156h | 35,880 |  |  |
| 79 | 3.9.1 | Final Design Review |  | 1d | 2018-07-18 | 2018-07-18 | 56, 77 | 302d | 0d | start no earlier than 2017-11-01 | LDRD Electronics Engineer; LDRD Mechnical Engineer; LDRD Physicist | 24h | 5,520 | DOE | LDRD |
| 80 | 3.9.2 | Incorporate Review Comments |  | 10d | 2018-07-19 | 2018-08-01 | 79 | 302d | 0d |  | LDRD Electronics Engineer [50%]; LDRD Mechnical Engineer [50%]; LDRD Physicist [50%] | 120h | 27,600 | DOE | LDRD |
| 81 | 3.9.3 | Complete Final CD-2/3 MAPS Design | milestone | 1d | 2018-08-02 | 2018-08-02 | 80 | 302d | 0d |  | LDRD Electronics Engineer [50%]; LDRD Mechnical Engineer [50%]; LDRD Physicist [50%] | 12h | 2,760 | DOE | LDRD |
| 82 | 3.10 | **Prototype Assembly and Test** |  | 90d | 2018-02-26 | 2018-06-29 |  | 139d |  |  |  | 600h | 81,360 |  | LDRD |
| 83 | 3.10.1 | Assemble prototype |  | 30d | 2018-02-26 | 2018-04-06 | 62, 27, 33, 36, 39, 42, 50, 51 | 139d | 0d |  | LDRD Electronics Tech [20%]; LDRD Mechnical Tech [20%]; LDRD Physicist [10%]; LDRD PostDoc [20%] | 168h | 24,240 |  | LDRD |
| 84 | 3.10.2 | Prototype Full System Test |  | 60d | 2018-04-09 | 2018-06-29 | 83 | 139d | 0d |  | Physicist [20%]; LDRD Physicist [20%]; LDRD PostDoc [30%]; LDRD Electronics Engineer [10%]; LDRD Mechnical Engineer [10%] | 432h | 57,120 |  | LDRD |
| 85 | 3.11 | **Softrware Development** |  | 500d | 2017-01-23 | 2018-12-21 |  | 201d |  |  |  | 3440h | 185,600 |  |  |
| 86 | 3.11.1 | Online Monitoring and Contorls |  | 200d | 2017-01-23 | 2017-10-27 | 19 | 201d | 0d |  | LDRD PostDoc [20%]; LDRD Physicist [10%]; Physicist [50%] | 1280h | 65,600 |  |  |
| 87 | 3.11.2 | Offline Software and Analysis |  | 300d | 2017-10-30 | 2018-12-21 | 86 | 201d |  |  | LDRD PostDoc [30%]; LDRD Physicist [10%]; Physicist [50%] | 2160h | 120,000 |  |  |
| 88 | 3.12 | Detector Optimizaation and Physics Simulations |  | 600d | 2016-10-03 | 2019-01-18 |  | 181d |  | start no earlier than 2016-10-03 | LDRD Physicist [50%]; LDRD PostDoc [50%] | 4800h | 768,000 |  |  |
| 89 | 3.13 | **Test Beam Operation** |  | 187d | 2019-01-11 | 2019-09-30 |  | 0d |  |  |  | 1318h | 99,620 |  | LDRD |
| 90 | 3.13.1 | Shipping/Transport |  | 10d | 2019-01-11 | 2019-01-24 | 84 | 0d |  | as late as possible | LDRD Mechnical Tech [20%] | 16h | 12,400 |  | LDRD |
| 91 | 3.13.2 | Setup |  | 5d | 2019-01-25 | 2019-01-31 | 90 | 0d |  | as late as possible | Physicist [50%]; LDRD Electronics Tech [50%]; LDRD Mechnical Tech [50%]; LDRD PostDoc [50%]; LDRD Physicist [10%] | 84h | 8,720 |  | LDRD |
| 92 | 3.13.3 | Operations |  | 20d | 2019-02-01 | 2019-02-28 | 91 | 0d |  | must start on 2019-02-01 | Physicist; LDRD Physicist [50%]; LDRD PostDoc [50%] | 160h | 12,800 |  | LDRD |
| 93 | 3.13.4 | Test Beam Data Analysis & Publication |  | 152d | 2019-03-01 | 2019-09-30 | 92 | 0d |  | finish no earlier than 2019-09-30 | LDRD Physicist [50%]; LDRD PostDoc [50%]; Physicist [50%] | 1058h | 65,700 |  |  |
