# MAPS Inner Barrel

Schedule from MS Project, 2016-10-03 to 2019-09-30, costs in $, A marks actual dates.
Guest Scientist, LANL

## Calendars

- Standard: Mon-Fri 08:00-12:00, 13:00-17:00; Sat-Sun off.

## Resources

| Resource | Rate | Cost per use |
| --- | --- | --- |
| Mech Liason Eng | 130 |  |
| Elec Liason Eng | 130 |  |
| Project Manager | 130 |  |
| Physicist |  |  |
| Elec tech | 97 |  |
| Mech Tech | 97 |  |
| Electronics Engineer | 130 |  |
| Mechanical Engineer | 130 |  |
| M&S |  | 1 |
| Electrical Engineer | 130 |  |
| LDRD Physicist | 230 |  |
| LDRD PostDoc | 90 |  |
| LDRD Electronics Engineer | 230 |  |
| LDRD Mechnical Engineer | 230 |  |
| LDRD Mechnical Tech | 150 |  |
| LDRD Electronics Tech | 150 |  |

## Schedule

| ID | WBS | Task | Type | Duration | Start | Finish | Predecessors | Complete | Remaining | Total slack | Free slack | Constraint | Resources | Work | Actual work | Cost | Actual cost | Activity | Cost Center |
| --- | --- | --- | --- | --- | --- | --- | --- | --- | --- | --- | --- | --- | --- | --- | --- | --- | --- | --- | --- |
| 1 | 1 | **ALICE ITS Key Tasks** |  | 0d | 2017-01-02 | 2017-01-02 |  |  |  |  |  |  |  |  |  |  |  |  |  |
| 2 | 1.1 | ALICE MAPS Production (7/17) |  | 240d? | 2016-11-28 | 2017-10-27 |  |  |  | 501d |  | start no earlier than 2016-11-28 |  |  |  |  |  |  |  |
| 3 | 1.2 | ALICE ITS IB FPC Production (9/17) |  | 135d | 2017-02-27 | 2017-09-01 |  |  |  | 541d |  | start no earlier than 2017-02-27 |  |  |  |  |  |  |  |
| 4 | 1.3 | ALICE ITS IB Stave Frame Production Ends (1/18) |  | 240d? | 2017-02-01 | 2018-01-02 |  |  |  | 454d |  | start no earlier than 2017-02-01 |  |  |  |  |  |  |  |
| 5 | 1.4 | ALICE ITS IB Stave Assembly (3/18) |  | 266d | 2017-02-27 | 2018-03-05 |  |  |  | 410d | 0d | finish no earlier than 2018-03-05 |  |  |  |  |  | ITS construction |  |
| 6 | 1.5 | ALICE ITS Electronics Pre-Production (7/17) |  | 100d | 2017-03-13 | 2017-07-28 |  |  |  | 139d | 0d | start no earlier than 2017-03-13 |  |  |  |  |  | ITS Electronics Pre-Production |  |
| 7 | 1.6 | ALICE ITS Electronics Production (6/18) |  | 240d | 2017-07-31 | 2018-06-29 | 6 |  |  | 326d |  | start no earlier than 2017-07-13 |  |  |  |  |  | ITS Electronics Production |  |
| 8 | 2 | **LDRD Milestones & Critical Tasks** |  | 781d | 2016-10-03 | 2019-09-30 |  |  |  | 0d |  |  |  |  |  |  |  |  |  |
| 9 | 2.1 | LDRD Start and End |  | 781d | 2016-10-03 | 2019-09-30 |  |  |  | 0d |  | start no earlier than 2016-10-03 |  |  |  |  |  |  |  |
| 10 | 2.2 | Complete MoU LANL-ALICE | milestone | 0d | 2016-12-09 | 2016-12-09 | 15 |  |  | 204d | 0d |  |  |  |  |  |  |  |  |
| 11 | 2.3 | Setup ALICE Readout Test Stands | milestone | 0d | 2017-09-15 | 2017-09-15 | 22 |  |  | 531d |  |  |  |  |  |  |  |  |  |
| 12 | 2.4 | Preliminary readout design to interface sPHENIX DAQ | milestone | 0d | 2017-11-01 | 2017-11-01 | 48 |  |  | 499d |  | start no earlier than 2017-11-01 |  |  |  |  |  |  |  |
| 13 | 2.5 | Prototype Test during sPHENIX Test Beam Run |  | 21d | 2019-02-01 | 2019-03-01 |  |  |  | 0d |  | start no earlier than 2019-02-01 |  |  |  |  |  |  | LDRD |
| 14 | 3 | **LANL LDRD** |  | 781d | 2016-10-03 A | 2019-09-30 |  | 1% | 774.35d | 0d |  |  |  | 20402h | 240h | 2,959,568 | 44,500 | LANL R&D | LDRD |
| 15 | 3.1 | MOU btw LANL and ALICE for R&D |  | 50d | 2016-10-03 | 2016-12-09 |  |  |  | 0d |  | start no earlier than 2016-10-03 | LDRD Physicist [20%] | 80h |  | 18,400 |  |  | LDRD |
| 16 | 3.2 | **Obtain Designs from ALICE** |  | 30d | 2016-12-12 | 2017-01-20 |  |  |  | 0d |  |  |  | 720h |  | 82,800 |  |  |  |
| 17 | 3.2.1 | Obtain Test Stand Design from CERN | milestone | 30d | 2016-12-12 | 2017-01-20 | 15 |  |  | 0d |  | start no earlier than 2016-10-03 | LDRD Electronics Engineer [50%]; Physicist [50%] | 240h |  | 27,600 |  |  | LDRD |
| 18 | 3.2.2 | Obtain ALICE Readout Unit Design | milestone | 30d | 2016-12-12 | 2017-01-20 | 15 |  |  | 174d | 0d |  | Physicist [50%]; LDRD Electronics Engineer [50%] | 240h |  | 27,600 |  |  | LDRD |
| 19 | 3.2.3 | obtain ALICE CAD model | milestone | 30d | 2016-12-12 | 2017-01-20 | 15 |  |  | 344d | 0d | start no earlier than 2016-06-01 | Physicist [50%]; LDRD Mechnical Engineer [50%] | 240h |  | 27,600 |  | ALICE CAD model | LDRD |
| 20 | 3.3 | **Setup Alice Readout Test Stand** |  | 200d | 2016-12-12 A | 2017-09-15 |  | 15% | 170d | 531d | 0d |  |  | 552h | 240h | 135,760 | 44,500 |  | LDRD |
| 21 | 3.3.1 | Procure 2 Test Stands and MAPS Evaluation Modules |  | 180d | 2016-12-12 A | 2017-08-18 | 17 | 17% | 150d | 449d | 0d |  | LDRD Electronics Tech [5%] | 280h | 240h | 92,000 | 44,500 |  | LDRD |
| 22 | 3.3.2 | Setup Test Stands |  | 20d | 2017-08-21 | 2017-09-15 | 21 |  |  | 531d | 0d |  | LDRD PostDoc; LDRD Electronics Tech [50%]; LDRD Physicist [20%] | 272h |  | 43,760 |  |  | LDRD |
| 23 | 3.4 | **Procure R&D ALICE Staves** |  | 195d | 2017-02-27 | 2017-11-24 |  |  |  | 204d |  |  |  | 4192h |  | 553,720 |  |  | LDRD |
| 24 | 3.4.1 | Procure and Produce 4 Staves |  | 180d | 2017-02-27 | 2017-11-03 | 15, 5SS |  |  | 204d | 0d |  | Physicist [50%]; LDRD Electronics Tech; LDRD PostDoc; LDRD Physicist [30%] | 4032h |  | 504,960 |  |  | LDRD |
| 25 | 3.4.2 | Test Staves at LANL |  | 20d | 2017-10-30 | 2017-11-24 | 24FS-5d |  |  | 204d | 65d |  | LDRD Physicist [20%]; LDRD PostDoc [50%]; LDRD Electronics Tech [30%] | 160h |  | 21,760 |  |  | LDRD |
| 26 | 3.4.3 | Travel and Per Diem Support |  | 180d | 2017-02-27 | 2017-11-03 | 24SS |  |  | 496d |  |  |  |  |  | 27,000 |  |  | LDRD |

Notes:
- 12: LDRD complete full readout electronics final design
- 14: LANL LDRD activities
- 15: Use ITS production line to train local people and produce staves for sPHENIX; / provide 1 FTE from 1/2017 - 6/2018+ for LDRD and later for sPHENIX
- 17: The readout test stand design has already been completed by ALICE.
- 19: Walt already obtained CAD model
- 21: Cost from Leo. Only a few custom boards, standard items standard: power supplies, etc. One stand would be procured early, one late, both under LDRD. / CERN-LANL MOU comes later in 2016, ~Dec. 2016? / Time needed to setup an CERN accout etc. may delay the actual procument date. MXL
- 22: LDRD PD + Tech, working with external collaorators/physicists
- 24: work on MOU to get 4 staves as early as possible; within 60 from the production ; / train LANL staff for MAPS assembly and test. M&S $20K for 6 months
- 25: assume testing 1 stave every two days;
- 26: $4.5K/month including lodging(100) and per diem (50) 1 FTE (combination of PD and staff) / for 6 months;

| ID | WBS | Task | Duration | Start | Finish | Predecessors | Total slack | Free slack | Constraint | Resources | Work | Cost | Cost Center |
| --- | --- | --- | --- | --- | --- | --- | --- | --- | --- | --- | --- | --- | --- |
| 27 | 3.5 | **Procure ALICE Electronics & Cables** | 205d | 2016-12-12 | 2017-09-22 |  | 204d |  |  |  | 702.4h | 150,020 | LDRD |
| 28 | 3.5.1 | **ALICE Readout Electronics Boards** | 140d | 2017-03-13 | 2017-09-22 |  | 139d |  |  |  | 486.4h | 75,920 |  |
| 29 | 3.5.1.1 | **Readout Units (RDOs)** | 140d | 2017-03-13 | 2017-09-22 |  | 139d |  |  |  | 272h | 41,280 |  |
| 30 | 3.5.1.1.1 | Procure 4 RDOs | 120d | 2017-03-13 | 2017-08-25 | 6SS, 15FS+1d | 139d | 0d |  | Physicist [5%]; LDRD Electronics Tech [5%] | 96h | 23,200 | LDRD |
| 31 | 3.5.1.1.2 | Test RDOs | 20d | 2017-08-28 | 2017-09-22 | 30 | 139d | 0d |  | Physicist [20%]; LDRD Electronics Tech [30%]; LDRD PostDoc [50%]; LDRD Physicist [10%] | 176h | 18,080 | LDRD |
| 32 | 3.5.1.2 | **Common Readout Units (CRUs)** | 140d | 2017-03-13 | 2017-09-22 |  | 139d |  |  |  | 214.4h | 34,640 |  |
| 33 | 3.5.1.2.1 | Procure 2 CRUs | 120d | 2017-03-13 | 2017-08-25 | 15FS+1d, 6SS | 139d | 0d |  | Physicist [2%]; LDRD Electronics Tech [2%] | 38.4h | 12,880 | LDRD |
| 34 | 3.5.1.2.2 | Test CRUs at LANL | 20d | 2017-08-28 | 2017-09-22 | 33 | 139d | 0d |  | Physicist [10%]; LDRD Electronics Tech [30%]; LDRD PostDoc [50%]; LDRD Physicist [20%] | 176h | 21,760 | LDRD |
| 35 | 3.5.2 | **SamTec Cables** | 32d | 2016-12-12 | 2017-01-24 |  | 312d |  |  |  | 20h | 5,000 |  |
| 36 | 3.5.2.1 | Procure 10 SamTec Cables | 30d | 2016-12-12 | 2017-01-20 | 10 | 312d | 0d |  | LDRD Electronics Tech [5%] | 12h | 3,800 | LDRD |
| 37 | 3.5.2.2 | Test Cables | 2d | 2017-01-23 | 2017-01-24 | 36 | 312d | 173d |  | LDRD Electronics Tech [50%] | 8h | 1,200 | LDRD |
| 38 | 3.5.3 | **Optical Cables** | 22d | 2016-12-13 | 2017-01-11 |  | 321d |  |  |  | 16h | 2,900 |  |
| 39 | 3.5.3.1 | Procure 5 Optical Cables | 20d | 2016-12-13 | 2017-01-09 | 36SS+1d | 321d | 0d |  | LDRD Electronics Tech [5%] | 8h | 1,700 | LDRD |
| 40 | 3.5.3.2 | Test Optical Cables | 2d | 2017-01-10 | 2017-01-11 | 39 | 321d | 182d |  | LDRD Electronics Tech [50%] | 8h | 1,200 | LDRD |
| 41 | 3.5.4 | **Procure Ancillaries** | 94d | 2016-12-13 | 2017-04-21 |  | 251d |  |  |  | 180h | 66,200 | LDRD |
| 42 | 3.5.4.1 | Procure LV,HV, controls | 90d | 2016-12-13 | 2017-04-17 | 20SS+1d | 251d | 0d | start no earlier than 2016-10-03 | Physicist [5%]; LDRD Electronics Tech [5%] | 72h | 35,400 | LDRD |
| 43 | 3.5.4.2 | Procure Racks | 90d | 2016-12-15 | 2017-04-19 | 42SS+2d | 251d | 0d | start no earlier than 2016-10-03 | LDRD Electronics Tech [5%] | 36h | 15,400 | LDRD |
| 44 | 3.5.4.3 | Procure Chiller | 90d | 2016-12-19 | 2017-04-21 | 43SS+2d | 526d | 15d |  | Physicist [5%]; LDRD Electronics Tech [5%] | 72h | 15,400 | LDRD |
| 45 | 3.6 | **Readout R&D** | 345d | 2017-01-23 | 2018-05-18 |  | 174d |  |  |  | 744h | 137,840 |  |
| 46 | 3.6.1 | Preliminary readout design and FPGA programing | 120d | 2017-01-23 | 2017-07-07 | 10, 17, 18 | 174d | 0d | start no earlier than 2017-01-20 | LDRD Electronics Engineer [20%]; LDRD PostDoc [10%] | 288h | 52,800 |  |
| 47 | 3.6.2 | Preliminary test of RDO with test bench | 20d | 2017-07-10 | 2017-08-04 | 46 | 174d | 0d |  | LDRD Electronics Tech [20%]; LDRD PostDoc [20%] | 64h | 7,680 |  |
| 48 | 3.6.3 | Test Preliminary Readout Design with RDO and CRU | 20d | 2017-09-25 | 2017-10-20 | 31, 34, 37, 40, 42, 43, 47 | 139d | 0d |  | LDRD Electronics Engineer [10%]; LDRD Electronics Tech [20%]; LDRD PostDoc [20%] | 80h | 11,360 |  |
| 49 | 3.6.4 | Readout design and test II | 90d | 2017-10-23 | 2018-02-23 | 48 | 139d | 0d |  | LDRD Electronics Engineer [20%]; LDRD Electronics Tech [10%] | 216h | 43,920 |  |
| 50 | 3.6.5 | Readout final design | 60d | 2018-02-26 | 2018-05-18 | 49 | 254d | 0d |  | LDRD Electronics Engineer [20%] | 96h | 22,080 |  |

Notes:
- 28: critical tasks
- 36: from DigiKey?

| ID | WBS | Task | Type | Duration | Start | Finish | Predecessors | Total slack | Free slack | Constraint | Resources | Work | Cost | Cost Center |
| --- | --- | --- | --- | --- | --- | --- | --- | --- | --- | --- | --- | --- | --- | --- |
| 51 | 3.7 | **Electronics Final Design Review** |  | 12d | 2018-05-21 | 2018-06-05 |  | 254d |  |  |  | 65.6h | 25,088 |  |
| 52 | 3.7.1 | Electronics Design Review |  | 1d | 2018-05-21 | 2018-05-21 | 31, 34, 21, 50 | 254d | 0d |  | LDRD Electronics Engineer; LDRD Physicist | 16h | 13,680 | LDRD |
| 53 | 3.7.2 | Incorporate Review Comments |  | 10d | 2018-05-22 | 2018-06-04 | 52 | 254d | 0d |  | LDRD Physicist [20%]; LDRD Electronics Engineer [30%] | 40h | 9,200 | LDRD |
| 54 | 3.7.3 | Complete Final Electronics Design | milestone | 1d | 2018-06-05 | 2018-06-05 | 53 | 254d | 0d |  | LDRD Physicist [20%]; LDRD Electronics Engineer | 9.6h | 2,208 | LDRD |
| 55 | 3.8 | Prototype readout assembled and tested |  | 90d | 2018-06-06 | 2018-10-09 | 54 | 254d |  |  | LDRD Electronics Tech [10%]; LDRD PostDoc [20%] | 216h | 23,760 |  |
| 56 | 3.9 | **Mechanical Support and Cooling** |  | 200d | 2017-01-23 | 2017-10-27 |  | 344d |  |  |  | 1004h | 236,160 |  |
| 57 | 3.9.1 | **Specifications** |  | 60d | 2017-01-23 | 2017-04-14 |  | 344d |  |  |  | 336h | 65,120 |  |
| 58 | 3.9.1.1 | Review & Simulate Heat Load |  | 40d | 2017-01-23 | 2017-03-17 | 19 | 344d | 0d | start no earlier than 2016-10-03 | LDRD Mechnical Engineer [30%]; LDRD Physicist [20%]; LDRD PostDoc [20%] | 224h | 42,560 | LDRD |
| 59 | 3.9.1.2 | review mechanical tolerances/distortions |  | 10d | 2017-03-20 | 2017-03-31 | 58 | 344d | 0d | start no earlier than 2004-10-01 | LDRD Mechnical Engineer [30%]; LDRD Physicist [30%] | 48h | 11,040 | LDRD |
| 60 | 3.9.1.3 | review disassembly/repair options |  | 10d | 2017-04-03 | 2017-04-14 | 59 | 344d | 0d | start no earlier than 2004-10-01 | LDRD Mechnical Tech [50%]; LDRD Physicist [30%] | 64h | 11,520 | LDRD |
| 61 | 3.9.2 | Prototype Stave Space Frame Design |  | 20d | 2017-04-17 | 2017-05-12 | 60 | 344d | 0d |  | LDRD Mechnical Engineer [50%]; LDRD Physicist [20%]; LDRD Mechnical Tech [30%] | 160h | 32,960 | LDRD |
| 62 | 3.9.3 | **Safety Systems** |  | 60d | 2017-08-07 | 2017-10-27 |  | 501d |  |  |  | 144h | 35,440 |  |
| 63 | 3.9.3.1 | review sensors & interlocks |  | 20d | 2017-08-07 | 2017-09-01 | 69, 47 | 501d | 0d |  | LDRD Electronics Tech [30%] | 48h | 7,200 | LDRD |
| 64 | 3.9.3.2 | electrical interlock design |  | 20d | 2017-09-04 | 2017-09-29 | 63 | 501d | 0d |  | LDRD Electronics Tech [30%] | 48h | 12,200 | LDRD |
| 65 | 3.9.3.3 | cooling interlocks design |  | 20d | 2017-10-02 | 2017-10-27 | 64 | 501d |  |  | LDRD Mechnical Engineer [30%] | 48h | 16,040 | LDRD |
| 66 | 3.9.4 | **Cooling System** |  | 50d | 2017-05-15 | 2017-07-21 | 44, 60 | 511d |  |  |  | 148h | 54,280 |  |
| 67 | 3.9.4.1 | Prototype Design (modify ALICE) |  | 10d | 2017-05-15 | 2017-05-26 | 58, 61 | 511d | 0d |  | LDRD Mechnical Engineer [30%]; LDRD Physicist [20%] | 40h | 9,200 | LDRD |
| 68 | 3.9.4.2 | Chiller |  | 30d | 2017-05-29 | 2017-07-07 | 67 | 511d | 0d |  | LDRD Electronics Tech [5%] | 12h | 21,800 |  |
| 69 | 3.9.4.3 | Mock up Testing |  | 10d | 2017-07-10 | 2017-07-21 | 68 | 511d | 10d |  | LDRD Mechnical Tech [50%]; LDRD Physicist [20%]; LDRD PostDoc [50%] | 96h | 23,280 | LDRD |
| 70 | 3.9.5 | **Stave Assembly Tooling** |  | 60d | 2017-05-29 | 2017-08-18 |  | 539d |  |  |  | 216h | 48,360 |  |
| 71 | 3.9.5.1 | Jig Design (modify ALICE) |  | 10d | 2017-05-29 | 2017-06-09 | 61, 67 | 539d | 0d |  | LDRD Mechnical Engineer [30%]; LDRD Physicist [10%] | 32h | 7,360 | LDRD |
| 72 | 3.9.5.2 | Prototype Jigs |  | 30d | 2017-06-12 | 2017-07-21 | 71 | 539d | 0d |  | LDRD PostDoc [20%]; LDRD Mechnical Tech [30%] | 120h | 20,120 | LDRD |
| 73 | 3.9.5.3 | Final Jigs Design and Production |  | 20d | 2017-07-24 | 2017-08-18 | 72 | 539d | 285d |  | LDRD Mechnical Engineer [10%]; LDRD Mechnical Tech [30%] | 64h | 20,880 | LDRD |
| 74 | 3.10 | **Prototype Assembly and Test** |  | 90d | 2018-02-26 | 2018-06-29 |  | 139d |  |  |  | 768h | 114,240 | LDRD |
| 75 | 3.10.1 | Assemble prototype |  | 30d | 2018-02-26 | 2018-04-06 | 61, 25, 31, 34, 37, 40, 48, 49 | 139d | 0d |  | LDRD Electronics Tech [20%]; LDRD Mechnical Tech [50%]; LDRD Physicist [10%]; LDRD PostDoc [20%] | 240h | 35,040 | LDRD |
| 76 | 3.10.2 | Prototype Full System Test |  | 60d | 2018-04-09 | 2018-06-29 | 75 | 139d | 0d |  | Physicist [20%]; LDRD Physicist [20%]; LDRD PostDoc [30%]; LDRD Electronics Engineer [10%]; LDRD Mechnical Engineer [30%] | 528h | 79,200 | LDRD |
| 77 | 3.11 | Mechanical Conceptual Design |  | 60d | 2018-07-02 | 2018-09-21 | 76 | 254d | 0d |  | LDRD Mechnical Engineer [10%]; LDRD Mechnical Tech [10%] | 96h | 18,240 |  |

Notes:
- 52: for CD-2
- 62: monitoring temp, flow rates, I, V etc.

| ID | WBS | Task | Type | Duration | Start | Finish | Predecessors | Total slack | Free slack | Constraint | Resources | Work | Cost | Cost Center |
| --- | --- | --- | --- | --- | --- | --- | --- | --- | --- | --- | --- | --- | --- | --- |
| 78 | 3.12 | **Mechanical Conceptual Design Review** |  | 12d | 2018-09-24 | 2018-10-09 |  | 254d |  |  |  | 104h | 33,920 |  |
| 79 | 3.12.1 | Mechanics Design Review |  | 1d | 2018-09-24 | 2018-09-24 | 69, 73, 77 | 254d | 0d |  | LDRD Mechnical Engineer; LDRD Physicist | 16h | 13,680 | LDRD |
| 80 | 3.12.2 | Incorporate Review Comments |  | 10d | 2018-09-25 | 2018-10-08 | 79 | 254d | 0d |  | LDRD Mechnical Engineer [50%]; LDRD Physicist [50%] | 80h | 18,400 | LDRD |
| 81 | 3.12.3 | Complete Mechanical Conceptual Design | milestone | 1d | 2018-10-09 | 2018-10-09 | 80 | 254d |  |  | LDRD Physicist [50%]; LDRD Mechnical Engineer [50%] | 8h | 1,840 | LDRD |
| 82 | 3.13 | **Softrware Tool Development and Analysis** |  | 500d | 2017-01-23 | 2018-12-21 |  | 201d |  |  |  | 4160h | 351,200 |  |
| 83 | 3.13.1 | FPGA, Online Monitoring and Contorls |  | 200d | 2017-01-23 | 2017-10-27 | 17 | 201d | 0d |  | LDRD PostDoc [20%]; LDRD Physicist [20%]; Physicist [50%]; LDRD Electronics Engineer [20%] | 1760h | 176,000 |  |
| 84 | 3.13.2 | Offline Software and Analysis |  | 300d | 2017-10-30 | 2018-12-21 | 83 | 201d |  |  | LDRD PostDoc [30%]; LDRD Physicist [20%]; Physicist [50%] | 2400h | 175,200 |  |
| 85 | 3.14 | **Detector Optimizaation and Physics Simulations (MIE)** |  | 700d | 2016-10-03 | 2019-06-07 |  | 81d |  |  |  | 5600h | 946,000 |  |
| 86 | 3.14.1 | MIE preproposal development |  | 300d | 2016-10-03 | 2017-11-24 |  | 81d | 0d | start no earlier than 2016-10-03 | LDRD Physicist [50%]; LDRD PostDoc [50%] | 2400h | 404,000 |  |
| 87 | 3.14.2 | MIE full proposal development and reviews |  | 400d | 2017-11-27 | 2019-06-07 | 86 | 81d |  |  | LDRD Physicist [50%]; LDRD PostDoc [50%] | 3200h | 542,000 |  |
| 88 | 3.15 | **Test Beam Operation** |  | 187d | 2019-01-11 | 2019-09-30 |  | 0d |  |  |  | 1398h | 132,420 | LDRD |
| 89 | 3.15.1 | Shipping/Transport |  | 10d | 2019-01-11 | 2019-01-24 | 76, 13SS-20d | 0d |  | as late as possible | LDRD Mechnical Tech [20%] | 16h | 12,400 | LDRD |
| 90 | 3.15.2 | Setup |  | 5d | 2019-01-25 | 2019-01-31 | 89 | 0d |  | as late as possible | Physicist [50%]; LDRD Electronics Tech [50%]; LDRD Mechnical Tech [50%]; LDRD PostDoc [50%]; LDRD Physicist [10%] | 84h | 8,720 | LDRD |
| 91 | 3.15.3 | Operations |  | 10d | 2019-02-01 | 2019-02-14 | 90 | 0d |  | must start on 2019-02-01 | Physicist; LDRD Physicist; LDRD PostDoc | 240h | 45,600 | LDRD |
| 92 | 3.15.4 | Test Beam Data Analysis & Publication |  | 152d | 2019-03-01 | 2019-09-30 | 91 | 0d |  | finish no earlier than 2019-09-30 | LDRD Physicist [50%]; LDRD PostDoc [50%]; Physicist [50%] | 1058h | 65,700 |  |

Notes:
- 78: For CD-1 review, 11/2017, conceptuall design of mechanis system
